# Work Break Down Leveled

Schedule from MS Project, 2004-01-12 to 2007-12-31, A marks actual dates.
Chesapeake Digital Solutions

## Calendars

- Standard: Mon-Fri 08:00-12:00, 13:00-17:00; Sat-Sun off.

## Resources

| Resource |
| --- |
| Latricia Simon |
| Daniel Tubbs |
| Jason Sadler |
| Brian Easton |
| Francis Deligosa |
| Joseph Williams |
| Computer Engineer |
| Technical Writer |
| Lawyer |
| Graphics Designer |
| Drafter |
| Contract Manufacturer |
| Parts Vendor |
| FCC Test Lab |
| Printers |
| Software Engineer |
| Sales Staff |
| Support Staff |
| Development Staff |

## Schedule

| ID | WBS | Task | Type | Duration | Start | Finish | Predecessors | Complete | Remaining | Total slack | Free slack | Resources | Work | Actual work |
| --- | --- | --- | --- | --- | --- | --- | --- | --- | --- | --- | --- | --- | --- | --- |
| 1 | 1 | **Phase 0 - Concept** |  | 81d | 2004-01-12 A | 2004-05-03 |  | 88% | 9.41d | 94d | 79d |  | 1803.2h | 1626.8h |
| 2 | 1.1 | Project Start | milestone | 0d | 2004-01-12 A | 2004-01-12 A |  | 100% |  |  |  | Daniel Tubbs; Latricia Simon; Jason Sadler; Brian Easton; Francis Deligosa; Joseph Williams |  |  |
| 3 | 1.2 | **Project Selection** |  | 23d | 2004-01-12 A | 2004-02-11 A |  | 100% |  |  |  |  | 288h | 288h |
| 4 | 1.2.1 | Project Topic Ideas |  | 1d | 2004-01-12 A | 2004-01-12 A |  | 100% |  |  |  | Daniel Tubbs; Latricia Simon; Jason Sadler; Brian Easton; Francis Deligosa; Joseph Williams | 8h | 8h |
| 5 | 1.2.2 | Team Members Selected |  | 3d | 2004-01-13 A | 2004-01-15 A |  | 100% |  |  |  | Daniel Tubbs [50%]; Latricia Simon [50%]; Jason Sadler [50%]; Brian Easton [50%]; Francis Deligosa [50%]; Joseph Williams [50%] | 24h | 24h |
| 6 | 1.2.3 | Team Organization |  | 5d | 2004-01-16 A | 2004-01-22 A | 5 | 100% |  |  |  | Daniel Tubbs [50%]; Latricia Simon [50%]; Jason Sadler [50%]; Brian Easton [50%]; Francis Deligosa [50%]; Joseph Williams [50%] | 40h | 40h |
| 7 | 1.2.4 | Define Team Responsibilities |  | 5d | 2004-01-23 A | 2004-01-29 A | 6 | 100% |  |  |  | Daniel Tubbs [50%]; Latricia Simon [50%]; Jason Sadler [50%]; Brian Easton [50%]; Francis Deligosa [50%]; Joseph Williams [50%] | 40h | 40h |
| 8 | 1.2.5 | Individual Project Research |  | 22d | 2004-01-13 A | 2004-02-11 A | 4 | 100% |  |  |  | Daniel Tubbs [50%]; Latricia Simon [50%]; Jason Sadler [50%]; Brian Easton [50%]; Francis Deligosa [50%]; Joseph Williams [50%] | 176h | 176h |
| 9 | 1.2.6 | Individual Project Presentation | milestone | 0d | 2004-02-11 A | 2004-02-11 A | 8 | 100% |  |  |  | Daniel Tubbs; Latricia Simon; Jason Sadler; Brian Easton; Francis Deligosa; Joseph Williams |  |  |
| 10 | 1.3 | **Projects Research** |  | 4d | 2004-02-12 A | 2004-02-17 A |  | 100% |  |  |  |  | 32h | 32h |
| 11 | 1.3.1 | Projects Research |  | 3d | 2004-02-12 A | 2004-02-16 A | 3 | 100% |  |  |  | Daniel Tubbs; Latricia Simon; Jason Sadler; Brian Easton; Francis Deligosa; Joseph Williams | 24h | 24h |
| 12 | 1.3.2 | Team Project Selection |  | 1d | 2004-02-17 A | 2004-02-17 A | 11 | 100% |  |  |  | Daniel Tubbs; Latricia Simon; Jason Sadler; Brian Easton; Francis Deligosa; Joseph Williams | 8h | 8h |
| 13 | 1.4 | **Feasibility Research** |  | 21d | 2004-02-18 A | 2004-03-17 A | 12, 10 | 100% |  |  |  |  | 504h | 504h |
| 14 | 1.4.1 | Market Research |  | 21d | 2004-02-18 A | 2004-03-17 A |  | 100% |  |  |  | Daniel Tubbs [25%]; Latricia Simon [25%]; Jason Sadler [20%]; Brian Easton [25%]; Francis Deligosa [25%]; Joseph Williams [25%] | 168h | 168h |
| 15 | 1.4.2 | Risk Analysis |  | 21d | 2004-02-18 A | 2004-03-17 A |  | 100% |  |  |  | Daniel Tubbs [25%]; Latricia Simon [25%]; Jason Sadler [20%]; Brian Easton [25%]; Francis Deligosa [25%]; Joseph Williams [25%] | 168h | 168h |
| 16 | 1.4.3 | Research Competitors |  | 21d | 2004-02-18 A | 2004-03-17 A |  | 100% |  |  |  | Daniel Tubbs [25%]; Latricia Simon [25%]; Jason Sadler [20%]; Brian Easton [25%]; Francis Deligosa [25%]; Joseph Williams [25%] | 168h | 168h |
| 17 | 1.4.4 | Feasibility Presentation | milestone | 0d | 2004-03-17 A | 2004-03-17 A | 16, 14, 15 | 100% |  |  |  | Daniel Tubbs; Latricia Simon; Jason Sadler; Brian Easton; Francis Deligosa; Joseph Williams |  |  |
| 18 | 1.5 | **Milestone Research** |  | 20d | 2004-03-18 A | 2004-04-14 | 13 | 99% | 0d | 94d |  |  | 262h | 262h |
| 19 | 1.5.1 | Work break Down Structure |  | 14d | 2004-03-18 A | 2004-04-06 A |  | 100% |  |  |  | Daniel Tubbs [75%]; Latricia Simon [75%]; Jason Sadler [60%]; Brian Easton [75%]; Francis Deligosa [75%]; Joseph Williams [75%] | 112h | 112h |
| 20 | 1.5.2 | Budget |  | 3d | 2004-04-07 A | 2004-04-09 A | 19 | 100% |  |  |  | Brian Easton [37%]; Joseph Williams [75%] | 24h | 24h |
| 21 | 1.5.3 | ROI Analysis |  | 3d | 2004-04-12 A | 2004-04-14 A | 20 | 100% |  |  |  | Brian Easton [75%] | 24h | 24h |
| 22 | 1.5.4 | Marketing Plan |  | 3d | 2004-04-07 A | 2004-04-09 A | 19 | 100% |  |  |  | Jason Sadler [60%] | 24h | 24h |
| 23 | 1.5.5 | Finance Plan |  | 3d | 2004-04-07 A | 2004-04-09 A | 19 | 100% |  |  |  | Brian Easton [37%] | 24h | 24h |
| 24 | 1.5.6 | Management Plan |  | 5d | 2004-04-07 A | 2004-04-13 A | 19 | 100% |  |  |  | Francis Deligosa [75%] | 30h | 30h |
| 25 | 1.5.7 | Evaluation Plan |  | 3d | 2004-04-07 A | 2004-04-09 A | 19 | 100% |  |  |  | Latricia Simon [75%] | 24h | 24h |
| 26 | 1.5.8 | Milestone Presentation | milestone | 0d | 2004-04-14 | 2004-04-14 | 22, 23, 24, 25, 21 |  |  | 94d | 0d | Daniel Tubbs; Latricia Simon; Jason Sadler; Brian Easton; Francis Deligosa; Joseph Williams |  |  |

| ID | WBS | Task | Type | Duration | Start | Finish | Predecessors | Complete | Remaining | Total slack | Free slack | Constraint | Resources | Work | Actual work |
| --- | --- | --- | --- | --- | --- | --- | --- | --- | --- | --- | --- | --- | --- | --- | --- |
| 27 | 1.6 | **SBIR Research** |  | 54d | 2004-02-18 A | 2004-05-03 | 13SS | 75% | 13.5d | 94d |  |  |  | 504.4h | 348.8h |
| 28 | 1.6.1 | SBIR Grant Proposal |  | 54d | 2004-02-18 A | 2004-05-03 |  | 75% | 13.5d | 94d | 0d |  | Daniel Tubbs [25%]; Latricia Simon [25%]; Jason Sadler [20%]; Brian Easton [25%]; Francis Deligosa [25%]; Joseph Williams [25%] | 504.4h | 348.8h |
| 29 | 1.6.2 | SBIR Grant Application & Presentation | milestone | 0d | 2004-05-03 | 2004-05-03 | 28 |  |  | 94d |  |  | Daniel Tubbs; Latricia Simon; Jason Sadler; Brian Easton; Francis Deligosa; Joseph Williams |  |  |
| 30 | 1.7 | **Website** |  | 54d | 2004-02-18 A | 2004-05-03 |  | 65% | 18.97d | 94d |  |  |  | 212.8h | 192h |
| 31 | 1.7.1 | Website Draft |  | 10d | 2004-02-18 A | 2004-03-02 A | 12 | 100% |  |  |  |  | Jason Sadler [20%] | 80h | 80h |
| 32 | 1.7.2 | Website Update 1 |  | 14d | 2004-03-18 A | 2004-04-06 A | 17 | 100% |  |  |  |  | Jason Sadler [20%] | 112h | 112h |
| 33 | 1.7.3 | Website Update 2 |  | 13d | 2004-04-15 | 2004-05-03 | 32, 26 |  |  | 94d | 0d |  | Jason Sadler [20%] | 20.8h |  |
| 34 | 1.7.4 | Website Complete | milestone | 0d | 2004-05-03 | 2004-05-03 | 33 |  |  | 94d |  |  | Jason Sadler |  |  |
| 35 | 2 | **Phase 1 - Proof of Concept** |  | 80d | 2004-08-23 | 2004-12-10 | 1 |  |  | 15d |  | start no earlier than 2004-08-23 |  | 1209.33h |  |
| 36 | 2.1 | Hire Personnel |  | 20d | 2004-08-23 | 2004-09-17 |  |  |  | 26d | 0d |  | Joseph Williams [10%] | 16h |  |
| 37 | 2.2 | **Build Lab Prototype** |  | 74.58d | 2004-08-23 | 2004-12-03 |  |  |  | 20.42d |  |  |  | 916.13h |  |
| 38 | 2.2.1 | **Prototype Documentation** |  | 15d | 2004-08-23 | 2004-09-10 |  |  |  | 21d |  |  |  | 146.72h |  |
| 39 | 2.2.1.1 | Prototype Specification |  | 12d | 2004-08-23 | 2004-09-07 |  |  |  | 21d | 0d |  | Daniel Tubbs; Latricia Simon [25%]; Francis Deligosa [25%]; Drafter [21%] | 118.72h |  |
| 40 | 2.2.1.2 | QA |  | 1d | 2004-09-08 | 2004-09-08 | 39 |  |  | 21d | 0d |  | Latricia Simon | 8h |  |
| 41 | 2.2.1.3 | Rework |  | 2d | 2004-09-09 | 2004-09-10 | 40 |  |  | 21d | 0d |  | Daniel Tubbs; Latricia Simon [25%]; Francis Deligosa [25%] | 20h |  |
| 42 | 2.2.1.4 | Prototype Specifications (Draft) Complete | milestone | 0d | 2004-09-10 | 2004-09-10 | 41 |  |  | 21d | 0d |  | Daniel Tubbs; Latricia Simon [25%]; Francis Deligosa [25%] |  |  |
| 43 | 2.2.1.5 | Prototype Specification Complete | milestone | 0d | 2004-09-10 | 2004-09-10 | 42 |  |  | 80d |  |  |  |  |  |
| 44 | 2.2.2 | **High Level Design** |  | 20d | 2004-09-13 | 2004-10-08 | 42 |  |  | 21d |  |  |  | 180h |  |
| 45 | 2.2.2.1 | Vendor Selection |  | 5d | 2004-09-13 | 2004-09-17 |  |  |  | 21d | 0d |  | Daniel Tubbs [25%]; Francis Deligosa [90%] | 46h |  |
| 46 | 2.2.2.2 | Parts Selection |  | 5d | 2004-09-20 | 2004-09-24 | 45 |  |  | 21d | 0d |  | Daniel Tubbs [25%]; Francis Deligosa [90%] | 46h |  |
| 47 | 2.2.2.3 | Acquire Parts |  | 10d | 2004-09-27 | 2004-10-08 | 46 |  |  | 21d | 0d |  | Francis Deligosa [10%]; Parts Vendor | 88h |  |
| 48 | 2.2.2.4 | Parts Acquired | milestone | 0d | 2004-10-08 | 2004-10-08 | 47 |  |  | 60d |  |  |  |  |  |
| 49 | 2.2.3 | **Develop Prototype** |  | 44.58d | 2004-09-20 | 2004-11-19 | 36 |  |  | 20.42d |  |  |  | 467.65h |  |
| 50 | 2.2.3.1 | **Computer Interface Module** |  | 29.58d | 2004-09-20 | 2004-10-29 |  |  |  | 21.42d | 0d |  |  | 83.36h |  |
| 51 | 2.2.3.1.1 | Design Circuits |  | 10d | 2004-09-20 | 2004-10-01 | 46FF |  |  | 26d | 5d |  | Daniel Tubbs [90%]; Computer Engineer [39%] | 39.36h |  |
| 52 | 2.2.3.1.2 | Build Circuit |  | 2d | 2004-10-13 | 2004-10-15 | 51, 47 |  |  | 20.42d | 0d |  | Daniel Tubbs [90%] | 14.4h |  |
| 53 | 2.2.3.1.3 | Test Circuit |  | 2d | 2004-10-19 | 2004-10-21 | 52 |  |  | 21.42d | 0d |  | Daniel Tubbs [90%] | 14.4h |  |
| 54 | 2.2.3.1.4 | QA |  | 1d | 2004-10-21 | 2004-10-22 | 53 |  |  | 21.42d | 0d |  | Latricia Simon | 8h |  |
| 55 | 2.2.3.1.5 | Rework |  | 1d | 2004-10-28 | 2004-10-29 | 54 |  |  | 21.42d | 0d |  | Daniel Tubbs [90%] | 7.2h |  |
| 56 | 2.2.3.1.6 | Computer Interface Complete | milestone | 0d | 2004-10-29 | 2004-10-29 | 55 |  |  | 21.42d |  |  |  |  |  |

| ID | WBS | Task | Type | Duration | Start | Finish | Predecessors | Total slack | Free slack | Resources | Work |
| --- | --- | --- | --- | --- | --- | --- | --- | --- | --- | --- | --- |
| 57 | 2.2.3.2 | **Dead Reckoning Module** |  | 27.58d | 2004-09-23 | 2004-11-01 |  | 20.42d | 0d |  | 101.6h |
| 58 | 2.2.3.2.1 | Design Circuits |  | 10d | 2004-09-23 | 2004-10-11 | 46FF | 23.42d | 0d | Daniel Tubbs [90%]; Computer Engineer [39%] | 57.6h |
| 59 | 2.2.3.2.2 | Build Circuit |  | 2d | 2004-10-15 | 2004-10-19 | 58, 47 | 21.42d | 0d | Daniel Tubbs [90%] | 14.4h |
| 60 | 2.2.3.2.3 | Test Circuit |  | 2d | 2004-10-25 | 2004-10-27 | 59 | 21.42d | 0d | Daniel Tubbs [90%] | 14.4h |
| 61 | 2.2.3.2.4 | QA |  | 1d | 2004-10-27 | 2004-10-28 | 60 | 21.42d | 0d | Latricia Simon | 8h |
| 62 | 2.2.3.2.5 | Rework |  | 1d | 2004-10-29 | 2004-11-01 | 61 | 20.42d | 0d | Daniel Tubbs [90%] | 7.2h |
| 63 | 2.2.3.2.6 | Dead Reckoning Module Complete | milestone | 0d | 2004-11-01 | 2004-11-01 | 62 | 20.42d |  |  |  |
| 64 | 2.2.3.3 | **802.15.4 Module** |  | 28.58d | 2004-09-20 | 2004-10-28 |  | 22.42d | 2d |  | 83.01h |
| 65 | 2.2.3.3.1 | Design Circuits |  | 6d | 2004-09-20 | 2004-09-29 | 46FF | 31d | 7d | Daniel Tubbs [90%]; Computer Engineer [39%] | 39.01h |
| 66 | 2.2.3.3.2 | Build Circuit |  | 2d | 2004-10-11 | 2004-10-13 | 65, 47 | 23.42d | 0d | Daniel Tubbs [90%] | 14.4h |
| 67 | 2.2.3.3.3 | Test Circuit |  | 2d | 2004-10-21 | 2004-10-25 | 66 | 23.42d | 0d | Daniel Tubbs [90%] | 14.4h |
| 68 | 2.2.3.3.4 | QA |  | 1d | 2004-10-25 | 2004-10-26 | 67 | 23.42d | 0d | Latricia Simon | 8h |
| 69 | 2.2.3.3.5 | Rework |  | 1d | 2004-10-27 | 2004-10-28 | 68 | 22.42d | 0d | Daniel Tubbs [90%] | 7.2h |
| 70 | 2.2.3.3.6 | 802.15.4 Module Complete | milestone | 0d | 2004-10-28 | 2004-10-28 | 69 | 22.42d |  |  |  |
| 71 | 2.2.3.4 | **Software Interface** |  | 14d | 2004-10-29 | 2004-11-18 | 50 | 21.42d | 1d |  | 73.12h |
| 72 | 2.2.3.4.1 | Design Software Interface |  | 8d | 2004-10-29 | 2004-11-10 |  | 21.42d | 0d | Brian Easton [90%]; Daniel Tubbs [10%] | 26.4h |
| 73 | 2.2.3.4.2 | Build Software Interface |  | 2d | 2004-11-10 | 2004-11-12 | 72 | 21.42d | 0d | Brian Easton [90%]; Daniel Tubbs [10%] | 16h |
| 74 | 2.2.3.4.3 | Test Software Interface |  | 2d | 2004-11-12 | 2004-11-16 | 73 | 21.42d | 0d | Brian Easton [90%]; Daniel Tubbs [10%] | 14.72h |
| 75 | 2.2.3.4.4 | QA |  | 1d | 2004-11-16 | 2004-11-17 | 74 | 21.42d | 0d | Latricia Simon | 8h |
| 76 | 2.2.3.4.5 | Rework |  | 1d | 2004-11-17 | 2004-11-18 | 75 | 21.42d | 0d | Brian Easton [90%]; Daniel Tubbs [10%] | 8h |
| 77 | 2.2.3.4.6 | Software Interface Complete | milestone | 0d | 2004-11-18 | 2004-11-18 | 76 | 21.42d |  |  |  |
| 78 | 2.2.3.5 | **Integrate Components** |  | 14d | 2004-11-01 | 2004-11-19 | 50, 57, 64 | 20.42d |  |  | 126.56h |
| 79 | 2.2.3.5.1 | Design Circuits |  | 8d | 2004-11-01 | 2004-11-11 |  | 20.42d | 0d | Daniel Tubbs [90%]; Computer Engineer [39%] | 82.56h |
| 80 | 2.2.3.5.2 | Build Circuit |  | 2d | 2004-11-11 | 2004-11-15 | 79 | 20.42d | 0d | Daniel Tubbs [90%] | 14.4h |
| 81 | 2.2.3.5.3 | Test Circuit |  | 2d | 2004-11-15 | 2004-11-17 | 80 | 20.42d | 0d | Daniel Tubbs [90%] | 14.4h |
| 82 | 2.2.3.5.4 | QA |  | 1d | 2004-11-17 | 2004-11-18 | 81 | 20.42d | 0d | Latricia Simon | 8h |
| 83 | 2.2.3.5.5 | Rework |  | 1d | 2004-11-18 | 2004-11-19 | 82 | 20.42d | 0d | Daniel Tubbs [90%] | 7.2h |
| 84 | 2.2.3.5.6 | Lab Prototype Built | milestone | 0d | 2004-11-19 | 2004-11-19 | 83 | 20.42d | 0d | Daniel Tubbs [90%] |  |

| ID | WBS | Task | Type | Duration | Start | Finish | Predecessors | Total slack | Free slack | Constraint | Resources | Work |
| --- | --- | --- | --- | --- | --- | --- | --- | --- | --- | --- | --- | --- |
| 85 | 2.2.4 | **Prototype Testing** |  | 4d | 2004-11-19 | 2004-11-25 | 84, 71 | 20.42d |  |  |  | 51.2h |
| 86 | 2.2.4.1 | Test Prototype |  | 2d | 2004-11-19 | 2004-11-23 |  | 20.42d | 0d |  | Daniel Tubbs [90%]; Brian Easton [90%] | 28.8h |
| 87 | 2.2.4.2 | QA |  | 1d | 2004-11-23 | 2004-11-24 | 86 | 20.42d | 0d |  | Latricia Simon | 8h |
| 88 | 2.2.4.3 | Rework |  | 1d | 2004-11-24 | 2004-11-25 | 87 | 20.42d | 0d |  | Daniel Tubbs [90%]; Brian Easton [90%] | 14.4h |
| 89 | 2.2.4.4 | Lab Prototype Testing Complete | milestone | 0d | 2004-11-25 | 2004-11-25 | 88 | 26.42d |  |  |  |  |
| 90 | 2.2.5 | Update Design Specifications |  | 5d | 2004-11-25 | 2004-12-02 | 88 | 20.42d | 0d |  | Daniel Tubbs [90%] | 36h |
| 91 | 2.2.6 | Product Specification (final) Complete | milestone | 0d | 2004-12-02 | 2004-12-02 | 90 | 20.42d | 0d |  | Daniel Tubbs [90%] |  |
| 92 | 2.2.7 | Prototype Demonstration |  | 1d | 2004-12-02 | 2004-12-03 | 91 | 20.42d |  |  | Daniel Tubbs; Latricia Simon; Jason Sadler; Brian Easton; Francis Deligosa; Joseph Williams | 34.56h |
| 93 | 2.3 | Webpage |  | 10d | 2004-11-18 | 2004-12-02 | 90FF | 21.42d |  |  | Jason Sadler [50%] | 40h |
| 94 | 2.4 | SBIR Phase 2 Application |  | 80d | 2004-08-23 | 2004-12-10 |  | 15d | 0d |  | Daniel Tubbs [10%]; Latricia Simon [10%]; Jason Sadler [10%]; Brian Easton [10%]; Francis Deligosa [10%]; Joseph Williams [10%] | 237.2h |
| 95 | 2.5 | SBIR Phase 2 Application Submitted | milestone | 0d | 2004-12-10 | 2004-12-10 | 94 | 15d |  |  | Daniel Tubbs; Latricia Simon; Jason Sadler; Brian Easton; Francis Deligosa; Joseph Williams |  |
| 96 | 3 | **Phase 2 - Product Development** |  | 347d | 2005-01-03 | 2006-05-02 | 35 | 0d |  | start no earlier than 2005-01-01 |  | 8027.67h |
| 97 | 3.1 | Obtain SBA Loan |  | 40d | 2005-01-03 | 2005-02-25 |  | 307d | 0d |  | Brian Easton [10%] | 32h |
| 98 | 3.2 | SBA Loan Obtained | milestone | 0d | 2005-02-25 | 2005-02-25 | 97 | 307d |  |  |  |  |
| 99 | 3.3 | Hire Staff - Phase 2 |  | 20d | 2005-04-05 | 2005-05-04 |  | 259d |  |  | Joseph Williams [10%] | 16h |
| 100 | 3.4 | **Software Development** |  | 192.5d | 2005-01-03 | 2005-09-28 |  | 154.5d |  |  |  | 3155.83h |
| 101 | 3.4.1 | Software Design |  | 30d | 2005-01-03 | 2005-02-11 |  | 154.5d | 0d |  | Francis Deligosa [50%]; Joseph Williams | 340h |
| 102 | 3.4.2 | Develop Integration Plan |  | 20d | 2005-01-03 | 2005-02-01 |  | 325d |  |  | Latricia Simon [90%]; Daniel Tubbs | 173.33h |
| 103 | 3.4.3 | **Database Development** |  | 61d | 2005-02-14 | 2005-05-09 | 101 | 256d |  |  |  | 669.6h |
| 104 | 3.4.3.1 | Database Selection |  | 10d | 2005-02-14 | 2005-02-25 |  | 275d | 0d |  | Joseph Williams; Jason Sadler | 128h |
| 105 | 3.4.3.2 | Finalize Database Design |  | 5d | 2005-03-01 | 2005-03-07 | 104 | 274d | 0d |  | Joseph Williams | 40h |
| 106 | 3.4.3.3 | Develop Assets Table |  | 5d | 2005-04-04 | 2005-04-08 | 105 | 274d | 0d |  | Jason Sadler | 40h |
| 107 | 3.4.3.4 | Develop History Table |  | 5d | 2005-03-29 | 2005-04-04 | 104 | 278d | 4d |  | Joseph Williams | 40h |
| 108 | 3.4.3.5 | QA |  | 1d | 2005-04-11 | 2005-04-11 | 107, 106 | 274d | 0d |  | Latricia Simon [90%] | 7.2h |
| 109 | 3.4.3.6 | Rework |  | 2d | 2005-04-12 | 2005-04-13 | 108 | 274d |  |  | Joseph Williams | 16h |

| ID | WBS | Task | Type | Duration | Start | Finish | Predecessors | Total slack | Free slack | Resources | Work |
| --- | --- | --- | --- | --- | --- | --- | --- | --- | --- | --- | --- |
| 110 | 3.4.3.7 | **Reports** |  | 55d | 2005-02-22 | 2005-05-09 |  | 256d |  |  | 398.4h |
| 111 | 3.4.3.7.1 | Finalize Report Design |  | 9d | 2005-02-22 | 2005-03-04 |  | 271d | 0d | Joseph Williams; Jason Sadler | 80h |
| 112 | 3.4.3.7.2 | List Reports Here! |  | 5d | 2005-03-07 | 2005-03-11 | 111 | 271d | 15d | Jason Sadler | 40h |
| 113 | 3.4.3.7.3 | List Reports Here! |  | 5d | 2005-03-08 | 2005-03-14 |  | 270d | 14d | Joseph Williams | 40h |
| 114 | 3.4.3.7.4 | Cost Per Use Report |  | 5d | 2005-03-14 | 2005-03-18 |  | 266d | 10d | Jason Sadler | 40h |
| 115 | 3.4.3.7.5 | Aging Report |  | 5d | 2005-03-15 | 2005-03-21 |  | 265d | 9d | Joseph Williams | 40h |
| 116 | 3.4.3.7.6 | Inventory Report |  | 5d | 2005-03-21 | 2005-03-25 |  | 261d | 5d | Jason Sadler | 40h |
| 117 | 3.4.3.7.7 | Missing Equipment Report |  | 5d | 2005-03-22 | 2005-03-28 |  | 260d | 4d | Joseph Williams | 40h |
| 118 | 3.4.3.7.8 | Equipment Utilization Report |  | 5d | 2005-03-28 | 2005-04-01 |  | 256d | 0d | Jason Sadler | 40h |
| 119 | 3.4.3.7.9 | QA |  | 2d | 2005-04-04 | 2005-04-05 | 118, 112, 113, 114, 115, 116, 117 | 256d | 0d | Latricia Simon [90%] | 14.4h |
| 120 | 3.4.3.7.10 | Rework |  | 3d | 2005-05-05 | 2005-05-09 | 119 | 256d | 0d | Joseph Williams | 24h |
| 121 | 3.4.3.8 | Database Development Complete | milestone | 0d | 2005-05-09 | 2005-05-09 | 120 | 256d |  |  |  |
| 122 | 3.4.4 | **Web Interface** |  | 128.13d | 2005-02-14 | 2005-08-11 | 101 | 154.5d | 0d |  | 1006.59h |
| 123 | 3.4.4.1 | Web server Selection |  | 10d | 2005-02-14 | 2005-03-07 |  | 154.5d | 0d | Francis Deligosa [90%]; Software Engineer | 115.08h |
| 124 | 3.4.4.2 | Finalize Web Interface Design |  | 10d | 2005-03-07 | 2005-03-21 | 123 | 154.5d | 0d | Francis Deligosa [90%]; Software Engineer | 151.52h |
| 125 | 3.4.4.3 | Mapping Module |  | 20d | 2005-03-21 | 2005-04-18 | 124 | 232.5d | 78d | Francis Deligosa | 160h |
| 126 | 3.4.4.4 | Setup Module |  | 20d | 2005-03-21 | 2005-04-18 | 124 | 232.5d | 78d | Software Engineer | 160h |
| 127 | 3.4.4.5 | Inventory Entry Module |  | 20d | 2005-04-18 | 2005-05-16 | 124 | 212.5d | 58d | Software Engineer | 160h |
| 128 | 3.4.4.6 | Alarm Module |  | 15d | 2005-04-18 | 2005-08-04 | 124 | 154.5d | 0d | Francis Deligosa | 120h |
| 129 | 3.4.4.7 | Help Screens |  | 10d | 2005-05-16 | 2005-05-30 | 124 | 202.5d | 48d | Software Engineer | 80h |
| 130 | 3.4.4.8 | QA |  | 2d | 2005-08-04 | 2005-08-08 | 129, 125, 126, 127, 128 | 154.5d | 0d | Latricia Simon [90%] | 14.4h |
| 131 | 3.4.4.9 | Rework |  | 3d | 2005-08-08 | 2005-08-11 | 130 | 154.5d | 0d | Francis Deligosa [90%]; Software Engineer | 45.6h |
| 132 | 3.4.4.10 | Web Interface Development Complete | milestone | 0d | 2005-08-11 | 2005-08-11 | 131 | 154.5d |  |  |  |
| 133 | 3.4.5 | **Integration Testing** |  | 34.38d | 2005-08-11 | 2005-09-28 | 122 | 154.5d |  |  | 966.3h |
| 134 | 3.4.5.1 | Hardware Testing |  | 15d | 2005-08-11 | 2005-09-01 |  | 173.87d |  | Daniel Tubbs | 120h |
| 135 | 3.4.5.2 | Database Testing |  | 15d | 2005-08-11 | 2005-09-01 |  | 158.87d | 0d | Francis Deligosa [90%]; Software Engineer | 228h |
| 136 | 3.4.5.3 | Reports Testing |  | 15d | 2005-09-01 | 2005-09-22 | 135 | 158.87d |  | Francis Deligosa [90%]; Software Engineer | 228h |

| ID | WBS | Task | Type | Duration | Start | Finish | Predecessors | Total slack | Free slack | Resources | Work |
| --- | --- | --- | --- | --- | --- | --- | --- | --- | --- | --- | --- |
| 137 | 3.4.5.4 | **Web Interface Testing** |  | 15d | 2005-08-11 | 2005-09-01 |  | 154.5d | 0d |  | 240h |
| 138 | 3.4.5.4.1 | Internet Explorer |  | 5d | 2005-08-11 | 2005-08-18 |  | 154.5d | 0d | Joseph Williams; Jason Sadler | 80h |
| 139 | 3.4.5.4.2 | Netscape |  | 5d | 2005-08-18 | 2005-08-25 | 138 | 154.5d | 0d | Joseph Williams; Jason Sadler | 80h |
| 140 | 3.4.5.4.3 | Pocket PC Testing |  | 5d | 2005-08-25 | 2005-09-01 | 139 | 154.5d |  | Joseph Williams; Jason Sadler | 80h |
| 141 | 3.4.5.5 | QA |  | 4d | 2005-09-01 | 2005-09-07 | 137 | 154.5d | 0d | Latricia Simon [90%] | 28.8h |
| 142 | 3.4.5.6 | Rework |  | 10d | 2005-09-07 | 2005-09-28 | 141 | 154.5d | 0d | Francis Deligosa [90%]; Jason Sadler; Joseph Williams; Daniel Tubbs | 121.5h |
| 143 | 3.4.5.7 | Integration Testing Complete | milestone | 0d | 2005-09-28 | 2005-09-28 | 142 | 154.5d |  |  |  |
| 144 | 3.5 | **Documentation** |  | 54.87d | 2005-01-03 | 2005-03-18 |  | 292.13d |  |  | 505.84h |
| 145 | 3.5.1 | **User Manual** |  | 24.87d | 2005-01-03 | 2005-02-04 |  | 292.13d | 0d |  | 108.89h |
| 146 | 3.5.1.1 | Write User Manual |  | 10d | 2005-01-03 | 2005-01-28 |  | 292.13d | 0d | Daniel Tubbs [75%]; Brian Easton [10%]; Francis Deligosa [10%]; Technical Writer | 79.79h |
| 147 | 3.5.1.2 | QA |  | 2d | 2005-01-28 | 2005-02-01 | 146 | 292.13d | 0d | Latricia Simon [90%] | 14.4h |
| 148 | 3.5.1.3 | Editing |  | 3d | 2005-02-01 | 2005-02-04 | 147 | 292.13d |  | Daniel Tubbs [75%]; Brian Easton [10%]; Francis Deligosa [10%]; Technical Writer | 14.69h |
| 149 | 3.5.2 | **Training Manual** |  | 15d | 2005-02-04 | 2005-02-25 | 145 | 292.13d | 0d |  | 201.98h |
| 150 | 3.5.2.1 | Write Training Manual |  | 10d | 2005-02-04 | 2005-02-18 |  | 292.13d | 0d | Daniel Tubbs [75%]; Brian Easton [10%]; Francis Deligosa [10%]; Technical Writer | 156h |
| 151 | 3.5.2.2 | QA |  | 2d | 2005-02-18 | 2005-02-22 | 150 | 292.13d | 0d | Latricia Simon [90%] | 14.4h |
| 152 | 3.5.2.3 | Editing |  | 3d | 2005-02-22 | 2005-02-25 | 151 | 292.13d | 0d | Daniel Tubbs [75%]; Brian Easton [10%]; Francis Deligosa [10%]; Technical Writer | 31.58h |
| 153 | 3.5.3 | **Training CBT** |  | 15d | 2005-02-25 | 2005-03-18 | 152, 149 | 292.13d |  |  | 194.97h |
| 154 | 3.5.3.1 | Create Training CBT |  | 10d | 2005-02-25 | 2005-03-11 | 146 | 292.13d | 0d | Daniel Tubbs [75%]; Brian Easton [10%]; Francis Deligosa [10%]; Technical Writer | 156h |
| 155 | 3.5.3.2 | QA |  | 2d | 2005-03-11 | 2005-03-15 | 154 | 292.13d | 0d | Latricia Simon [90%] | 14.4h |
| 156 | 3.5.3.3 | Editing |  | 3d | 2005-03-15 | 2005-03-18 | 155 | 292.13d |  | Daniel Tubbs [75%]; Brian Easton [10%]; Francis Deligosa [10%]; Technical Writer | 24.57h |
| 157 | 3.5.3.4 | Documentation Complete | milestone | 0d | 2005-02-25 | 2005-02-25 |  | 307.13d |  |  |  |
| 158 | 3.6 | **Sample Production** |  | 82d | 2005-01-03 | 2005-04-26 |  | 0d |  |  | 436h |
| 159 | 3.6.1 | Contract Vendor Selection |  | 15d | 2005-01-03 | 2005-01-21 |  | 0d |  | Francis Deligosa [50%]; Daniel Tubbs [25%]; Contract Manufacturer | 160h |
| 160 | 3.6.2 | Plastic Tooling |  | 15d | 2005-01-21 | 2005-02-11 | 159 | 52d |  | Francis Deligosa [10%]; Contract Manufacturer [33%] | 12h |
| 161 | 3.6.3 | Engineering |  | 15d | 2005-01-21 | 2005-02-11 | 159 | 0d |  | Francis Deligosa [10%]; Contract Manufacturer [33%] | 12h |
| 162 | 3.6.4 | Sample Run |  | 30d | 2005-02-11 | 2005-03-25 | 161 | 0d |  | Francis Deligosa [10%]; Contract Manufacturer [33%] | 79.2h |
| 163 | 3.6.5 | Hardware Testing |  | 15d | 2005-03-28 | 2005-04-15 | 162 | 0d |  | Daniel Tubbs | 120h |
| 164 | 3.6.6 | QA |  | 4d | 2005-04-18 | 2005-04-21 | 163 | 0d |  | Latricia Simon [90%] | 28.8h |
| 165 | 3.6.7 | Update Design Specification |  | 3d | 2005-04-22 | 2005-04-26 | 164 | 0d |  | Daniel Tubbs [50%]; Francis Deligosa [50%] | 24h |
| 166 | 3.6.8 | Design Finalized | milestone | 0d | 2005-04-26 | 2005-04-26 | 165 | 0d |  |  |  |

| ID | WBS | Task | Type | Duration | Start | Finish | Predecessors | Total slack | Free slack | Constraint | Resources | Work |
| --- | --- | --- | --- | --- | --- | --- | --- | --- | --- | --- | --- | --- |
| 167 | 3.7 | **Finalize Production** |  | 185d | 2005-04-27 | 2006-01-10 | 158 | 0d |  |  |  | 1402h |
| 168 | 3.7.1 | Plastic Tooling Update |  | 30d | 2005-04-27 | 2005-06-07 |  | 0d |  |  | Francis Deligosa [10%]; Contract Manufacturer [33%] | 103.2h |
| 169 | 3.7.2 | Engineering |  | 15d | 2005-04-27 | 2005-05-17 |  | 15d |  |  | Francis Deligosa [10%]; Contract Manufacturer [33%] | 51.6h |
| 170 | 3.7.3 | Sample Run 2 |  | 30d | 2005-06-08 | 2005-07-19 | 169, 168 | 0d |  |  | Francis Deligosa [10%]; Contract Manufacturer [33%] | 103.2h |
| 171 | 3.7.4 | Retest Hardware |  | 15d | 2005-07-20 | 2005-08-09 | 170 | 105d | 0d |  | Daniel Tubbs | 120h |
| 172 | 3.7.5 | QA Certification |  | 5d | 2005-08-10 | 2005-08-16 | 171 | 105d |  |  | Latricia Simon [90%] | 36h |
| 173 | 3.7.6 | FCC Approval Testing |  | 60d | 2005-07-20 | 2005-10-11 | 170 | 0d |  |  | FCC Test Lab; Latricia Simon [10%] | 528h |
| 174 | 3.7.7 | FCC Approval Paper work |  | 60d | 2005-10-12 | 2006-01-03 | 173 | 0d |  |  | FCC Test Lab; Latricia Simon [10%] | 328h |
| 175 | 3.7.8 | FCC Approval Received | milestone | 0d | 2006-01-03 | 2006-01-03 | 174 | 0d |  |  | FCC Test Lab; Latricia Simon [10%] |  |
| 176 | 3.7.9 | FCC Labeling |  | 15d | 2005-12-21 | 2006-01-10 | 175FF+5d | 0d |  |  | Printers; Latricia Simon [10%] | 132h |
| 177 | 3.7.10 | STATags ready for Real World Testing | milestone | 0d | 2006-01-10 | 2006-01-10 | 176, 178 | 0d |  |  |  |  |
| 178 | 3.8 | **Legal** |  | 180d | 2005-01-03 | 2005-09-09 |  | 87d |  |  |  | 360h |
| 179 | 3.8.1 | Develop EULA |  | 20d | 2005-01-03 | 2005-01-28 |  | 87d | 0d |  | Lawyer [25%] | 40h |
| 180 | 3.8.2 | Liability Study |  | 80d | 2005-01-31 | 2005-05-20 | 179 | 87d | 0d |  | Lawyer [25%] | 160h |
| 181 | 3.8.3 | 25 |  | 80d | 2005-05-23 | 2005-09-09 | 180 | 87d |  |  | Lawyer [25%] | 160h |
| 182 | 3.9 | **Real-World Testing** |  | 80d | 2006-01-11 | 2006-05-02 | 167 | 0d |  |  |  | 920h |
| 183 | 3.9.1 | **Phase 1 - Ward** |  | 34d | 2006-01-11 | 2006-02-27 |  | 0d |  |  |  | 392h |
| 184 | 3.9.1.1 | Hospital Installation - Ward |  | 15d | 2006-01-11 | 2006-01-31 |  | 0d |  |  | Joseph Williams | 120h |
| 185 | 3.9.1.2 | Debugging & Enhancements |  | 15d | 2006-02-01 | 2006-02-21 | 184 | 0d |  | finish no earlier than 2004-02-20 | Joseph Williams; Francis Deligosa | 240h |
| 186 | 3.9.1.3 | QA |  | 4d | 2006-02-22 | 2006-02-27 | 185 | 0d |  | finish no earlier than 2004-02-20 | Latricia Simon | 32h |
| 187 | 3.9.2 | **Phase 2 - Floor** |  | 23d | 2006-02-28 | 2006-03-30 | 183 | 0d |  |  |  | 264h |
| 188 | 3.9.2.1 | Hospital Installation - Floor |  | 10d | 2006-02-28 | 2006-03-13 |  | 0d |  |  | Joseph Williams | 80h |
| 189 | 3.9.2.2 | Debugging & Enhancements |  | 10d | 2006-03-14 | 2006-03-27 | 188 | 0d |  | finish no earlier than 2004-02-06 | Joseph Williams; Francis Deligosa | 160h |
| 190 | 3.9.2.3 | QA |  | 3d | 2006-03-28 | 2006-03-30 | 189 | 0d |  | finish no earlier than 2004-02-06 | Latricia Simon | 24h |

| ID | WBS | Task | Type | Duration | Start | Finish | Predecessors | Total slack | Free slack | Constraint | Resources | Work |
| --- | --- | --- | --- | --- | --- | --- | --- | --- | --- | --- | --- | --- |
| 191 | 3.9.3 | **Phase 3 - Entire Hospital** |  | 23d | 2006-03-31 | 2006-05-02 | 187 | 0d |  |  |  | 264h |
| 192 | 3.9.3.1 | Hospital Installation - Whole Hospital |  | 10d | 2006-03-31 | 2006-04-13 |  | 0d |  |  | Joseph Williams | 80h |
| 193 | 3.9.3.2 | Debugging & Enhancements |  | 10d | 2006-04-14 | 2006-04-27 | 192 | 0d |  | finish no earlier than 2004-02-06 | Francis Deligosa; Joseph Williams | 160h |
| 194 | 3.9.3.3 | QA |  | 3d | 2006-04-28 | 2006-05-02 | 193 | 0d |  | finish no earlier than 2004-02-06 | Latricia Simon | 24h |
| 195 | 3.9.3.4 | STATags Ready for Sale | milestone | 0d | 2006-05-02 | 2006-05-02 | 194 | 0d |  |  |  |  |
| 196 | 3.10 | Marketing |  | 150d | 2005-10-05 | 2006-05-02 | 182FF | 0d |  |  | Jason Sadler | 1200h |
| 197 | 4 | **Phase 3 - Production Out Years** |  | 434d | 2006-05-03 | 2007-12-31 | 96 | 0d |  |  |  | 10824h |
| 198 | 4.1 | Hire Personnel |  | 30d | 2006-05-03 | 2006-06-13 |  | 0d |  |  | Joseph Williams [10%] | 24h |
| 199 | 4.2 | Product Ramp up |  | 70d | 2006-05-03 | 2006-08-08 |  | 364d | 0d |  | Francis Deligosa [10%]; Contract Manufacturer [10%] | 112h |
| 200 | 4.3 | Full Production | milestone | 0d | 2006-08-08 | 2006-08-08 | 199 | 364d |  |  |  |  |
| 201 | 4.4 | Establish Support Department |  | 20d | 2006-06-14 | 2006-07-11 | 198 | 0d |  |  | Joseph Williams | 160h |
| 202 | 4.5 | Support Department Established | milestone | 0d | 2006-07-11 | 2006-07-11 | 201 | 384d |  |  |  |  |
| 203 | 4.6 | Train Installation Engineers |  | 40d | 2006-06-14 | 2006-08-08 | 198 | 364d | 0d |  | Daniel Tubbs; Brian Easton | 640h |
| 204 | 4.7 | Installation Engineers Trained | milestone | 0d | 2006-08-08 | 2006-08-08 | 203 | 364d |  |  |  |  |
| 205 | 4.8 | **Marketing/Sales** |  | 404d | 2006-06-14 | 2007-12-31 | 198 | 0d |  |  |  | 3232h |
| 206 | 4.8.1 | Tradeshows |  | 404d | 2006-06-14 | 2007-12-31 |  | 0d |  |  | Sales Staff [15%] | 484.8h |
| 207 | 4.8.2 | Publications |  | 404d | 2006-06-14 | 2007-12-31 |  | 0d |  |  | Sales Staff [25%] | 808h |
| 208 | 4.8.3 | Marketing |  | 404d | 2006-06-14 | 2007-12-31 |  | 0d |  |  | Sales Staff [50%] | 1616h |
| 209 | 4.8.4 | Develop New Markets |  | 404d | 2006-06-14 | 2007-12-31 |  | 0d |  |  | Sales Staff [10%] | 323.2h |
| 210 | 4.9 | **Support** |  | 384d | 2006-07-12 | 2007-12-31 | 198, 201 | 0d |  |  |  | 6144h |
| 211 | 4.9.1 | Software Updates |  | 384d | 2006-07-12 | 2007-12-31 |  | 0d |  |  | Development Staff | 3072h |
| 212 | 4.9.2 | Warranty Support |  | 384d | 2006-07-12 | 2007-12-31 |  | 0d |  |  | Support Staff [50%] | 1536h |
| 213 | 4.9.3 | Telephone Support |  | 384d | 2006-07-12 | 2007-12-31 |  | 0d |  |  | Support Staff [50%] | 1536h |
| 214 | 4.10 | **Plastic Tool Replacement** |  | 360d | 2006-08-15 | 2007-12-31 |  | 0d |  |  |  | 512h |
| 215 | 4.10.1 | Plastic Tool Replacement (every 50000 units) |  | 20d | 2006-09-01 | 2006-09-28 |  | 327d |  | start no earlier than 2006-09-01 | Francis Deligosa [10%]; Contract Manufacturer [10%] | 32h |
| 216 | 4.10.2 | Plastic Tool Replacement (every 50000 units) |  | 20d | 2006-10-02 | 2006-10-27 |  | 306d |  | start no earlier than 2006-10-02 | Francis Deligosa [10%]; Contract Manufacturer [10%] | 32h |
| 217 | 4.10.3 | Plastic Tool Replacement (every 50000 units) |  | 20d | 2006-11-01 | 2006-11-28 |  | 284d |  | start no earlier than 2006-11-01 | Francis Deligosa [10%]; Contract Manufacturer [10%] | 32h |
| 218 | 4.10.4 | Plastic Tool Replacement (every 50000 units) |  | 20d | 2006-12-01 | 2006-12-28 |  | 262d |  | start no earlier than 2006-12-01 | Francis Deligosa [10%]; Contract Manufacturer [10%] | 32h |
| 219 | 4.10.5 | Plastic Tool Replacement (every 50000 units) |  | 20d | 2007-01-01 | 2007-01-26 |  | 241d |  | start no earlier than 2007-01-01 | Francis Deligosa [10%]; Contract Manufacturer [10%] | 32h |
| 220 | 4.10.6 | Plastic Tool Replacement (every 50000 units) |  | 20d | 2007-02-01 | 2007-02-28 |  | 198d | 0d | start no earlier than 2007-02-01 | Francis Deligosa [10%]; Contract Manufacturer [10%] | 32h |
| 221 | 4.10.7 | Plastic Tool Replacement (every 50000 units) |  | 20d | 2007-03-01 | 2007-03-28 | 220 | 198d |  |  | Francis Deligosa [10%]; Contract Manufacturer [10%] | 32h |
| 222 | 4.10.8 | Plastic Tool Replacement (every 50000 units) |  | 20d | 2007-04-02 | 2007-04-27 |  | 176d |  | start no earlier than 2007-04-02 | Francis Deligosa [10%]; Contract Manufacturer [10%] | 32h |
| 223 | 4.10.9 | Plastic Tool Replacement (every 50000 units) |  | 20d | 2007-05-01 | 2007-05-28 |  | 155d |  | start no earlier than 2007-05-01 | Francis Deligosa [10%]; Contract Manufacturer [10%] | 32h |
| 224 | 4.10.10 | Plastic Tool Replacement (every 50000 units) |  | 20d | 2007-06-01 | 2007-06-28 |  | 132d |  | start no earlier than 2007-06-01 | Francis Deligosa [10%]; Contract Manufacturer [10%] | 32h |
| 225 | 4.10.11 | Plastic Tool Replacement (every 50000 units) |  | 20d | 2007-07-02 | 2007-07-27 |  | 111d |  | start no earlier than 2007-07-02 | Francis Deligosa [10%]; Contract Manufacturer [10%] | 32h |
| 226 | 4.10.12 | Plastic Tool Replacement (every 50000 units) |  | 20d | 2007-08-01 | 2007-08-28 |  | 89d |  | start no earlier than 2007-08-01 | Francis Deligosa [10%]; Contract Manufacturer [10%] | 32h |
| 227 | 4.10.13 | Plastic Tool Replacement (every 50000 units) |  | 20d | 2007-09-03 | 2007-09-28 |  | 66d |  | start no earlier than 2007-09-03 | Francis Deligosa [10%]; Contract Manufacturer [10%] | 32h |
| 228 | 4.10.14 | Plastic Tool Replacement (every 50000 units) |  | 20d | 2007-10-01 | 2007-10-26 |  | 46d |  | start no earlier than 2007-10-01 | Francis Deligosa [10%]; Contract Manufacturer [10%] | 32h |
| 229 | 4.10.15 | Plastic Tool Replacement (every 50000 units) |  | 20d | 2007-11-01 | 2007-11-28 |  | 23d |  | start no earlier than 2007-11-01 | Francis Deligosa [10%]; Contract Manufacturer [10%] | 32h |
| 230 | 4.10.16 | Plastic Tool Replacement (every 50000 units) |  | 20d | 2007-12-04 | 2007-12-31 |  | 0d |  | finish no earlier than 2007-12-31 | Francis Deligosa [10%]; Contract Manufacturer [10%] | 32h |
| 231 | 4.10.17 | Break Even Point | milestone | 0d | 2006-08-15 | 2006-08-15 |  | 360d |  | start no earlier than 2006-08-15 |  |  |
